# 大荔经济技术开发区“智慧园区”服务平台-软件 施工开发计划

Schedule from MS Project, 2024-03-25 to 2024-12-24, A marks actual dates.
Microsoft

## Calendars

- 标准: Mon-Fri 08:00-12:00, 13:00-17:00; Sat-Sun off.

## Resources

| Resource |
| --- |
| 王明军 |
| 徐兴国 |
| 叶伟 |
| 周威志 |
| 石鑫 |
| 高亚杰 |
| 钱谷阳 |
| 单少康 |
| 谷笑星 |
| 董先超 |
| 张文 |

## Schedule

| ID | WBS | Task | Type | Duration | Start | Finish | Predecessors | Complete | Remaining | Constraint | Resources | Work | Actual work | 百分比 |
| --- | --- | --- | --- | --- | --- | --- | --- | --- | --- | --- | --- | --- | --- | --- |
| 1 | 1 | **大荔经济技术开发区“智慧园区”服务平台-软件** |  | 197d | 2024-03-25 A | 2024-12-24 |  | 27% | 143.02d |  | 王明军; 徐兴国; 叶伟; 周威志; 石鑫; 高亚杰; 钱谷阳; 单少康; 谷笑星; 董先超; 张文 | 28640h | 2923.13h |  |
| 2 | 1.1 | **一.数字驾驶舱** |  | 52d | 2024-03-25 A | 2024-06-04 |  | 58% | 22.02d |  | 王明军 | 1383h | 691.5h |  |
| 3 | 1.1.1 | 1.需求调研 | manual | 10d | 2024-03-25 A | 2024-04-08 A |  | 100% |  |  | 石鑫 | 80h | 80h |  |
| 4 | 1.1.2 | **2.系统软件开发** |  | 42d | 2024-04-08 A | 2024-06-04 |  | 46% | 22.88d |  | 王明军 | 887h | 389.25h |  |
| 5 | 1.1.2.1 | 综合态势 | manual | 5.88d | 2024-04-08 A | 2024-04-15 A |  | 100% |  | finish no earlier than 2024-04-15 | 单少康; 董先超 | 87h | 87h |  |
| 6 | 1.1.2.2 | 经济运行 | manual | 5d | 2024-04-16 A | 2024-04-23 A |  | 100% |  |  | 董先超; 单少康 | 80h | 80h |  |
| 7 | 1.1.2.3 | 精准招商 | manual | 5d | 2024-04-24 A | 2024-05-01 A |  | 100% |  | start no earlier than 2024-04-24 | 单少康; 董先超 | 80h | 80h |  |
| 8 | 1.1.2.4 | 项目资源 | manual | 5d | 2024-05-06 A | 2024-05-13 |  |  | 5d | start no earlier than 2024-05-06 | 单少康; 董先超 | 80h |  |  |
| 9 | 1.1.2.5 | 产业资源 | manual | 5d | 2024-05-14 | 2024-05-21 |  |  |  | start no earlier than 2024-05-14 | 单少康; 董先超 | 80h |  |  |
| 10 | 1.1.2.6 | 市政排水 | manual | 5d | 2024-05-22 | 2024-05-29 |  |  |  | start no earlier than 2024-05-22 | 单少康; 董先超 | 80h |  |  |
| 11 | 1.1.2.7 | 安环监测 | manual | 4d | 2024-05-30 | 2024-06-04 | 10 |  |  | finish no earlier than 2024-06-04 | 单少康; 董先超 | 64h |  |  |
| 12 | 1.2 | **二.精准招商管理** |  | 56d | 2024-03-25 A | 2024-06-10 |  | 54% | 25.92d |  | 叶伟 | 5017h | 2231.63h | 0% |
| 13 | 1.2.1 | 1.需求调研 | manual | 10d | 2024-04-09 A | 2024-04-23 A |  | 100% |  |  | 石鑫 | 80h | 80h |  |
| 14 | 1.2.2 | **2.系统软件开发** |  | 56d | 2024-03-25 A | 2024-06-10 |  | 51% | 27.59d |  | 高亚杰 | 4489h | 1911h |  |
| 15 | 1.2.2.1 | **招商热力图** |  | 56d | 2024-03-25 A | 2024-06-10 |  | 50% | 28.13d |  | 谷笑星; 钱谷阳 | 1728h | 844h |  |
| 16 | 1.2.2.1.1 | 招商首页 | manual | 9d | 2024-03-25 A | 2024-04-05 A |  | 100% |  |  | 谷笑星; 钱谷阳 | 144h | 144h |  |
| 17 | 1.2.2.1.2 | 园区主导产业 | manual | 9d | 2024-04-05 A | 2024-04-18 A |  | 100% |  |  | 谷笑星; 钱谷阳 | 144h | 144h |  |
| 18 | 1.2.2.1.3 | 工业地产 | manual | 9d | 2024-04-19 A | 2024-05-02 |  | 88% | 1.12d |  | 谷笑星; 钱谷阳 | 144h | 126h |  |
| 19 | 1.2.2.1.4 | 投资咨询 | manual | 9d | 2024-05-03 A | 2024-05-16 |  |  | 9d |  | 谷笑星; 钱谷阳 | 144h |  |  |
| 20 | 1.2.2.1.5 | 导引微信小程序 | manual | 9d | 2024-05-16 | 2024-05-29 |  |  |  |  | 谷笑星; 钱谷阳 | 144h |  |  |
| 21 | 1.2.2.1.6 | VR全景 | manual | 7d | 2024-05-30 | 2024-06-10 |  |  |  |  | 谷笑星; 钱谷阳 | 112h |  |  |
| 22 | 1.2.2.2 | **大数据精准招商** |  | 56d | 2024-03-25 A | 2024-06-10 |  | 53% | 26.06d |  | 徐兴国; 高亚杰 | 1473h | 446h |  |
| 23 | 1.2.2.2.1 | 产业链招商 | manual | 7d | 2024-03-25 A | 2024-04-03 A |  | 100% |  |  | 徐兴国; 高亚杰 | 56h | 56h |  |
| 24 | 1.2.2.2.2 | 企业关系链招商 | manual | 7d | 2024-04-05 A | 2024-04-16 A |  | 100% |  |  | 徐兴国; 高亚杰 | 56h | 56h |  |
| 25 | 1.2.2.2.3 | 地图招商 | manual | 7d | 2024-04-08 A | 2024-04-17 A |  | 100% |  |  | 徐兴国; 高亚杰 | 56h | 56h |  |
| 26 | 1.2.2.2.4 | 行业榜单 | manual | 7d | 2024-04-18 A | 2024-04-29 A |  | 100% |  |  | 徐兴国; 高亚杰 | 56h | 56h |  |
| 27 | 1.2.2.2.5 | 产业主题库 | manual | 7d | 2024-04-30 A | 2024-05-09 |  | 13% | 6.12d |  | 徐兴国; 高亚杰 | 105h | 7h |  |
| 28 | 1.2.2.2.6 | 企业猎搜 | manual | 7d | 2024-05-10 A | 2024-05-21 |  |  | 7d |  | 徐兴国; 高亚杰 | 112h |  |  |
| 29 | 1.2.2.2.7 | 关键词引擎 | manual | 7d | 2024-05-22 | 2024-05-31 |  |  |  |  | 徐兴国; 高亚杰 | 112h |  |  |
| 30 | 1.2.2.2.8 | 产业情报 | manual | 5d | 2024-06-03 | 2024-06-10 |  |  |  |  | 徐兴国; 高亚杰 | 80h |  |  |

| ID | WBS | Task | Type | Duration | Start | Finish | Complete | Remaining | Resources | Work | Actual work |
| --- | --- | --- | --- | --- | --- | --- | --- | --- | --- | --- | --- |
| 31 | 1.2.2.3 | **招商合同及履约管理** |  | 56d | 2024-03-25 A | 2024-06-10 | 49% | 28.71d | 周威志 | 840h | 406h |
| 32 | 1.2.2.3.1 | 合同管理合同添加 | manual | 7d | 2024-03-25 A | 2024-04-03 A | 100% |  | 周威志 | 56h | 56h |
| 33 | 1.2.2.3.2 | 合同管理基本信息 | manual | 7d | 2024-04-04 A | 2024-04-15 A | 100% |  | 周威志 | 56h | 56h |
| 34 | 1.2.2.3.3 | 合同管理合同进度管理 | manual | 7d | 2024-04-16 A | 2024-04-25 A | 100% |  | 周威志 | 56h | 56h |
| 35 | 1.2.2.3.4 | 合同管理资料管理 | manual | 7d | 2024-04-26 A | 2024-05-07 | 41% | 4.12d | 周威志 | 56h | 23h |
| 36 | 1.2.2.3.5 | 合同管理变更管理 | manual | 7d | 2024-05-08 A | 2024-05-17 |  | 7d | 周威志 | 56h |  |
| 37 | 1.2.2.3.6 | 合同管理验收管理 | manual | 6d | 2024-05-20 | 2024-05-28 |  |  | 周威志 | 48h |  |
| 38 | 1.2.2.3.7 | 合同管理绩效评价 | manual | 8d | 2024-05-29 | 2024-06-10 |  |  | 周威志 | 64h |  |
| 39 | 1.3 | **三.智慧物业管理** |  | 46d | 2024-04-11 | 2024-06-13 |  |  | 徐兴国 | 368h |  |
| 40 | 1.3.1 | 1.需求调研 | manual | 8d | 2024-04-11 | 2024-04-22 |  |  |  |  |  |
| 41 | 1.3.2 | **2.系统软件开发** |  | 43d | 2024-04-16 | 2024-06-13 |  |  |  |  |  |
| 42 | 1.3.2.1 | **智慧停车** |  | 26d | 2024-04-16 | 2024-05-21 |  |  |  |  |  |
| 43 | 1.3.2.1.1 | 停车总览停车位概况 | manual | 1d? | 2024-04-16 | 2024-04-17 |  |  |  |  |  |
| 44 | 1.3.2.1.2 | 停车总览本月停车时长占比 | manual | 1d | 2024-04-16 | 2024-04-17 |  |  |  |  |  |
| 45 | 1.3.2.1.3 | 停车总览设备统计 | manual | 1d | 2024-04-16 | 2024-04-17 |  |  |  |  |  |
| 46 | 1.3.2.1.4 | 停车总览今日时段车位占用统计 | manual | 1d | 2024-04-16 | 2024-04-17 |  |  |  |  |  |
| 47 | 1.3.2.1.5 | 停车总览停车位类型占比 | manual | 1d | 2024-04-16 | 2024-04-17 |  |  |  |  |  |
| 48 | 1.3.2.1.6 | 停车总览违停实时告警 | manual | 1d | 2024-04-16 | 2024-04-17 |  |  |  |  |  |
| 49 | 1.3.2.1.7 | 停车总览当前车位占用情况 | manual | 1d | 2024-04-16 | 2024-04-17 |  |  |  |  |  |
| 50 | 1.3.2.1.8 | 停车总览车辆过期提醒 | manual | 1d | 2024-04-16 | 2024-04-17 |  |  |  |  |  |
| 51 | 1.3.2.1.9 | 停车总览车辆进出记录 | manual | 1d | 2024-04-16 | 2024-04-17 |  |  |  |  |  |
| 52 | 1.3.2.1.10 | 停车场管理 | manual | 1d | 2024-04-16 | 2024-04-17 |  |  |  |  |  |
| 53 | 1.3.2.1.11 | 停车出入记录 | manual | 1d | 2024-04-16 | 2024-04-17 |  |  |  |  |  |
| 54 | 1.3.2.1.12 | 违停规则管理 | manual | 1d | 2024-04-16 | 2024-04-17 |  |  |  |  |  |
| 55 | 1.3.2.1.13 | 车辆管理 | manual | 1d | 2024-04-16 | 2024-04-17 |  |  |  |  |  |
| 56 | 1.3.2.1.14 | 停车引导屏控制 | manual | 1d | 2024-04-16 | 2024-04-17 |  |  |  |  |  |

| ID | WBS | Task | Type | Duration | Start | Finish | Resources | Work |
| --- | --- | --- | --- | --- | --- | --- | --- | --- |
| 57 | 1.3.2.2 | **物业管理** |  | 17d | 2024-05-22 | 2024-06-13 |  |  |
| 58 | 1.3.2.2.1 | 物业综合分析本周公告浏览热度 TOP5 | manual | 1d | 2024-05-22 | 2024-05-23 |  |  |
| 59 | 1.3.2.2.2 | 物业综合分析效率分析 | manual | 1d | 2024-05-22 | 2024-05-23 |  |  |
| 60 | 1.3.2.2.3 | 物业综合分析公告通知统计 | manual | 1d | 2024-05-22 | 2024-05-23 |  |  |
| 61 | 1.3.2.2.4 | 物业综合分析物业报修统计 | manual | 1d | 2024-05-22 | 2024-05-23 |  |  |
| 62 | 1.3.2.2.5 | 物业综合分析意见反馈统计 | manual | 1d | 2024-05-22 | 2024-05-23 |  |  |
| 63 | 1.3.2.2.6 | 物业综合分析意见反馈类型占比 | manual | 1d | 2024-05-22 | 2024-05-23 |  |  |
| 64 | 1.3.2.2.7 | 物业综合分析近7天巡检任务统计 | manual | 1d | 2024-05-22 | 2024-05-23 |  |  |
| 65 | 1.3.2.2.8 | 报修服务 | manual | 1d | 2024-05-22 | 2024-05-23 |  |  |
| 66 | 1.3.2.2.9 | 物业巡检 | manual | 1d | 2024-05-22 | 2024-05-23 |  |  |
| 67 | 1.4 | **四.园区资产管理** |  | 55d | 2024-04-23 | 2024-07-08 | 叶伟 | 440h |
| 68 | 1.4.1 | 1.需求调研 | manual | 15d | 2024-04-23 | 2024-05-11 |  |  |
| 69 | 1.4.2 | **2.系统软件开发** |  | 52d | 2024-04-26 | 2024-07-08 |  |  |
| 70 | 1.4.2.1 | **资产管理** |  | 21d | 2024-04-26 | 2024-05-24 |  |  |
| 71 | 1.4.2.1.1 | 系统登录 | manual | 1d? | 2024-04-26 | 2024-04-29 |  |  |
| 72 | 1.4.2.1.2 | 综合统计 | manual | 1d | 2024-04-26 | 2024-04-29 |  |  |
| 73 | 1.4.2.1.3 | 资产管理 | manual | 1d | 2024-04-26 | 2024-04-29 |  |  |
| 74 | 1.4.2.1.4 | 资产运营 | manual | 1d | 2024-04-26 | 2024-04-29 |  |  |
| 75 | 1.4.2.1.5 | 资产地图 | manual | 1d | 2024-04-26 | 2024-04-29 |  |  |
| 76 | 1.4.2.1.6 | 巡检养护 | manual | 1d | 2024-04-26 | 2024-04-29 |  |  |
| 77 | 1.4.2.1.7 | 系统管理 | manual | 1d | 2024-04-26 | 2024-04-29 |  |  |
| 78 | 1.4.2.2 | **资产管理系统移动端** |  | 16d | 2024-05-27 | 2024-06-17 |  |  |
| 79 | 1.4.2.2.1 | 物业综合分析本周公告浏览热度 TOP5 | manual | 1d | 2024-05-27 | 2024-05-28 |  |  |
| 80 | 1.4.2.2.2 | 物业综合分析效率分析 | manual | 1d | 2024-05-27 | 2024-05-28 |  |  |
| 81 | 1.4.2.2.3 | 物业综合分析公告通知统计 | manual | 1d | 2024-05-27 | 2024-05-28 |  |  |
| 82 | 1.4.2.2.4 | 物业综合分析物业报修统计 | manual | 1d | 2024-05-27 | 2024-05-28 |  |  |
| 83 | 1.4.2.2.5 | 物业综合分析意见反馈统计 | manual | 1d | 2024-05-27 | 2024-05-28 |  |  |
| 84 | 1.4.2.2.6 | 物业综合分析意见反馈类型占比 | manual | 1d | 2024-05-27 | 2024-05-28 |  |  |
| 85 | 1.4.2.2.7 | 物业综合分析近7天巡检任务统计 | manual | 1d | 2024-05-27 | 2024-05-28 |  |  |
| 86 | 1.4.2.2.8 | 报修服务 | manual | 1d | 2024-05-27 | 2024-05-28 |  |  |
| 87 | 1.4.2.2.9 | 物业巡检 | manual | 1d | 2024-05-27 | 2024-05-28 |  |  |

| ID | WBS | Task | Type | Duration | Start | Finish | Resources | Work |
| --- | --- | --- | --- | --- | --- | --- | --- | --- |
| 88 | 1.4.2.3 | **运营服务** |  | 15d | 2024-06-18 | 2024-07-08 |  |  |
| 89 | 1.4.2.3.1 | 平台登录 | manual | 1d | 2024-06-18 | 2024-06-19 |  |  |
| 90 | 1.4.2.3.2 | 可视化系统 | manual | 1d | 2024-06-18 | 2024-06-19 |  |  |
| 91 | 1.4.2.3.3 | 运营服务 | manual | 1d | 2024-06-18 | 2024-06-19 |  |  |
| 92 | 1.4.2.3.4 | 系统管理 | manual | 1d | 2024-06-18 | 2024-06-19 |  |  |
| 93 | 1.5 | **五.产业经济大脑** |  | 117d | 2024-05-23 | 2024-11-01 | 周威志 | 936h |
| 94 | 1.5.1 | 1.需求调研 | manual | 18d | 2024-05-23 | 2024-06-16 |  |  |
| 95 | 1.5.2 | **2.系统软件开发** |  | 84d | 2024-07-09 | 2024-11-01 |  |  |
| 96 | 1.5.2.1 | **经济运行指标库管理** |  | 10d | 2024-07-09 | 2024-07-22 |  |  |
| 97 | 1.5.2.1.1 | 基础指标管理 | manual | 1d? | 2024-07-09 | 2024-07-10 |  |  |
| 98 | 1.5.2.1.2 | 指标维度属性管理 | manual | 1d | 2024-07-09 | 2024-07-10 |  |  |
| 99 | 1.5.2.1.3 | 指标责任部门管理 | manual | 1d | 2024-07-09 | 2024-07-10 |  |  |
| 100 | 1.5.2.1.4 | 指标报送机制管理 | manual | 1d | 2024-07-09 | 2024-07-10 |  |  |
| 101 | 1.5.2.1.5 | 指标基础库 | manual | 1d | 2024-07-09 | 2024-07-10 |  |  |
| 102 | 1.5.2.2 | **经济运行分析系统** |  | 10d | 2024-07-23 | 2024-08-05 |  |  |
| 103 | 1.5.2.2.1 | 概况指标查看 | manual | 1d | 2024-07-23 | 2024-07-24 |  |  |
| 104 | 1.5.2.2.2 | 区域对标专题 | manual | 1d | 2024-07-23 | 2024-07-24 |  |  |
| 105 | 1.5.2.2.3 | 工业经济运行专题 | manual | 1d | 2024-07-23 | 2024-07-24 |  |  |
| 106 | 1.5.2.2.4 | 产业分析报告 | manual | 1d | 2024-07-23 | 2024-07-24 |  |  |
| 107 | 1.5.2.3 | **高质量评价系统** |  | 10d | 2024-08-06 | 2024-08-19 |  |  |
| 108 | 1.5.2.3.1 | 园区高质量发展 | manual | 1d | 2024-08-06 | 2024-08-07 |  |  |
| 109 | 1.5.2.3.2 | 产业/企业高质量发展 | manual | 1d | 2024-08-06 | 2024-08-07 |  |  |
| 110 | 1.5.2.3.3 | 重点企业分析企业全景画像 | manual | 1d | 2024-08-06 | 2024-08-07 |  |  |
| 111 | 1.5.2.3.4 | 重点企业分析标杆区域企业分析对比 | manual | 1d | 2024-08-06 | 2024-08-07 |  |  |
| 112 | 1.5.2.3.5 | 重点企业分析企业多维筛选 | manual | 1d | 2024-08-06 | 2024-08-07 |  |  |
| 113 | 1.5.2.3.6 | 重点企业分析区域创新指标对比 | manual | 1d | 2024-08-06 | 2024-08-07 |  |  |
| 114 | 1.5.2.3.7 | 重点企业分析优质企业模型 | manual | 1d | 2024-08-06 | 2024-08-07 |  |  |
| 115 | 1.5.2.3.8 | 重点企业分析风险企业模型 | manual | 1d | 2024-08-06 | 2024-08-07 |  |  |

| ID | WBS | Task | Type | Duration | Start | Finish | Resources | Work |
| --- | --- | --- | --- | --- | --- | --- | --- | --- |
| 116 | 1.5.2.4 | **产业企业培育分析** |  | 10d | 2024-08-20 | 2024-09-02 |  |  |
| 117 | 1.5.2.4.1 | 产业培育数据库 | manual | 1d | 2024-08-20 | 2024-08-21 |  |  |
| 118 | 1.5.2.4.2 | 产业培育模型 | manual | 1d | 2024-08-20 | 2024-08-21 |  |  |
| 119 | 1.5.2.4.3 | 培育企业“ 一企一档” | manual | 1d | 2024-08-20 | 2024-08-21 |  |  |
| 120 | 1.5.2.5 | **产业链图谱** |  | 10d | 2024-09-03 | 2024-09-14 |  |  |
| 121 | 1.5.2.5.1 | 产业链发展情况 | manual | 1d? | 2024-09-03 | 2024-09-04 |  |  |
| 122 | 1.5.2.5.2 | 产业分布情况 | manual | 1d | 2024-09-03 | 2024-09-04 |  |  |
| 123 | 1.5.2.5.3 | 标杆城市创新指数排名对比 | manual | 1d | 2024-09-03 | 2024-09-04 |  |  |
| 124 | 1.5.2.5.4 | 产业链上下游分析 | manual | 1d | 2024-09-03 | 2024-09-04 |  |  |
| 125 | 1.5.2.5.5 | 产业人才情况 | manual | 1d | 2024-09-03 | 2024-09-04 |  |  |
| 126 | 1.5.2.6 | **产业人才画像** |  | 19d | 2024-09-18 | 2024-10-12 |  |  |
| 127 | 1.5.2.6.1 | 产业人才全景画像 | manual | 1d? | 2024-09-18 | 2024-09-19 |  |  |
| 128 | 1.5.2.6.2 | 标杆区域人才对比分析 | manual | 1d | 2024-09-18 | 2024-09-19 |  |  |
| 129 | 1.5.2.6.3 | 相邻区域人才对比分析 | manual | 1d | 2024-09-18 | 2024-09-19 |  |  |
| 130 | 1.5.2.6.4 | 产业人才报表 | manual | 1d | 2024-09-18 | 2024-09-19 |  |  |
| 131 | 1.5.2.6.5 | 专家人才精准画像 | manual | 1d | 2024-09-18 | 2024-09-19 |  |  |
| 132 | 1.5.2.7 | **多链协同** |  | 15d | 2024-10-14 | 2024-11-01 |  |  |
| 133 | 1.5.2.7.1 | 产业对标分析 | manual | 1d? | 2024-10-14 | 2024-10-15 |  |  |
| 134 | 1.5.2.7.2 | 供应链风险预警 | manual | 1d | 2024-10-14 | 2024-10-15 |  |  |
| 135 | 1.5.2.7.3 | 协同监测 | manual | 1d | 2024-10-14 | 2024-10-15 |  |  |
| 136 | 1.5.2.7.4 | 资金流向分析 | manual | 1d | 2024-10-14 | 2024-10-15 |  |  |
| 138 | 1.6 | **六.园区能耗监测预警** |  | 56d | 2024-06-17 | 2024-09-02 | 钱谷阳 | 448h |
| 139 | 1.6.1 | 1.需求调研 | manual | 7d | 2024-06-17 | 2024-06-25 |  |  |
| 140 | 1.6.2 | **2.系统软件开发** |  | 40d | 2024-07-09 | 2024-09-02 |  |  |
| 141 | 1.6.2.1 | **水电能耗监测** |  | 10d | 2024-07-09 | 2024-07-22 |  |  |
| 142 | 1.6.2.1.1 | 上月能耗统计 | manual | 1d? | 2024-07-09 | 2024-07-10 |  |  |
| 143 | 1.6.2.1.2 | 每月能耗达标率 | manual | 1d | 2024-07-09 | 2024-07-10 |  |  |
| 144 | 1.6.2.1.3 | 设备统计 | manual | 1d | 2024-07-09 | 2024-07-10 |  |  |
| 145 | 1.6.2.1.4 | 近5天能耗统计 | manual | 1d | 2024-07-09 | 2024-07-10 |  |  |
| 146 | 1.6.2.1.5 | 月能耗及趋势 | manual | 1d | 2024-07-09 | 2024-07-10 |  |  |
| 147 | 1.6.2.1.6 | 上月能耗TOP10 | manual | 1d | 2024-07-09 | 2024-07-10 |  |  |

| ID | WBS | Task | Type | Duration | Start | Finish | Resources | Work |
| --- | --- | --- | --- | --- | --- | --- | --- | --- |
| 148 | 1.6.2.2 | **智慧路灯** |  | 20d | 2024-07-23 | 2024-08-19 |  |  |
| 149 | 1.6.2.2.1 | 定时开关灯控制 | manual | 1d | 2024-07-23 | 2024-07-24 |  |  |
| 150 | 1.6.2.2.2 | 远程化实时性监控 | manual | 1d | 2024-07-23 | 2024-07-24 |  |  |
| 151 | 1.6.2.2.3 | 监测数据管理 | manual | 1d | 2024-07-23 | 2024-07-24 |  |  |
| 152 | 1.6.2.2.4 | 故障报警 | manual | 1d | 2024-07-23 | 2024-07-24 |  |  |
| 153 | 1.6.2.2.5 | 路灯状态查询 | manual | 1d | 2024-07-23 | 2024-07-24 |  |  |
| 154 | 1.6.2.2.6 | 智能路灯一张图 | manual | 1d | 2024-07-23 | 2024-07-24 |  |  |
| 155 | 1.6.2.2.7 | 智能路灯数据整理 | manual | 1d | 2024-07-23 | 2024-07-24 |  |  |
| 156 | 1.6.2.2.8 | 视频数据治理 | manual | 1d | 2024-07-23 | 2024-07-24 |  |  |
| 157 | 1.6.2.2.9 | 数据统计 | manual | 1d | 2024-07-23 | 2024-07-24 |  |  |
| 158 | 1.6.2.3 | **充电桩管理** |  | 10d | 2024-08-20 | 2024-09-02 |  |  |
| 159 | 1.6.2.3.1 | 概况统计 | manual | 1d | 2024-08-20 | 2024-08-21 |  |  |
| 160 | 1.6.2.3.2 | 近7天充电量统计 | manual | 1d | 2024-08-20 | 2024-08-21 |  |  |
| 161 | 1.6.2.3.3 | 本月充电桩充电量TOP5 | manual | 1d | 2024-08-20 | 2024-08-21 |  |  |
| 162 | 1.6.2.3.4 | 充电桩设备能耗列表 | manual | 1d | 2024-08-20 | 2024-08-21 |  |  |
| 168 | 1.7 | **七.园区应急联动管理** |  | 103d | 2024-06-26 | 2024-11-15 | 单少康 | 824h |
| 169 | 1.7.1 | 1.需求调研 | manual | 4d | 2024-06-26 | 2024-06-30 |  |  |
| 170 | 1.7.2 | **2.系统软件开发** |  | 46d | 2024-09-14 | 2024-11-15 |  |  |
| 171 | 1.7.2.1 | **应急资源库** |  | 6d | 2024-09-14 | 2024-09-20 |  |  |
| 172 | 1.7.2.1.1 | 应急地图 | manual | 1d? | 2024-09-14 | 2024-09-16 |  |  |
| 173 | 1.7.2.2 | **结构化预案管理** |  | 6d | 2024-09-23 | 2024-09-30 |  |  |
| 174 | 1.7.2.2.1 | 知识抽取 | manual | 1d | 2024-09-23 | 2024-09-24 |  |  |
| 175 | 1.7.2.3 | **应急响应与联动指挥系统** |  | 6d | 2024-10-08 | 2024-10-15 |  |  |
| 176 | 1.7.2.3.1 | 知识融合 | manual | 1d | 2024-10-08 | 2024-10-09 |  |  |

| ID | WBS | Task | Type | Duration | Start | Finish | Resources | Work |
| --- | --- | --- | --- | --- | --- | --- | --- | --- |
| 177 | 1.7.2.4 | **应急辅助决策系统** |  | 24d | 2024-10-15 | 2024-11-15 |  |  |
| 178 | 1.7.2.4.1 | 应急“ 一张图” | manual | 1d | 2024-10-15 | 2024-10-16 |  |  |
| 179 | 1.7.2.4.2 | 生成应急处置方案园区关系图谱 | manual | 1d | 2024-10-15 | 2024-10-16 |  |  |
| 180 | 1.7.2.4.3 | 应急物资调度企业关系图谱 | manual | 1d | 2024-10-15 | 2024-10-16 |  |  |
| 181 | 1.7.2.4.4 | 在线监控信息调度 | manual | 1d | 2024-10-15 | 2024-10-16 |  |  |
| 182 | 1.7.2.4.5 | 事故影响辅助分析系统 | manual | 1d | 2024-10-15 | 2024-10-16 |  |  |
| 187 | 1.8 | **八.园区排水综合管理** |  | 109d | 2024-07-01 | 2024-11-28 | 谷笑星 | 872h |
| 188 | 1.8.1 | 1.需求调研 | manual | 11d | 2024-07-01 | 2024-07-15 |  |  |
| 189 | 1.8.2 | **2.系统软件开发** |  | 55d | 2024-09-14 | 2024-11-28 |  |  |
| 190 | 1.8.2.1 | **管线普查采集** |  | 6d | 2024-09-14 | 2024-09-20 |  |  |
| 191 | 1.8.2.1.1 | 管线普查采集 | manual | 1d? | 2024-09-14 | 2024-09-16 |  |  |
| 192 | 1.8.2.2 | **管道疏通及检测** |  | 6d | 2024-09-21 | 2024-09-27 |  |  |
| 193 | 1.8.2.2.1 | 管道疏通及检测 | manual | 1d | 2024-09-21 | 2024-09-23 |  |  |
| 194 | 1.8.2.3 | **数据规整融合建库** |  | 8d | 2024-09-28 | 2024-10-08 |  |  |
| 195 | 1.8.2.3.1 | 数据规整融合建库 | manual | 1d | 2024-09-28 | 2024-09-30 |  |  |
| 196 | 1.8.2.4 | **排水管网监** |  | 23d | 2024-10-09 | 2024-11-08 |  |  |
| 197 | 1.8.2.4.1 | 基础设置设备管理 | manual | 1d | 2024-10-09 | 2024-10-10 |  |  |
| 198 | 1.8.2.4.2 | 基础设置监测管理 | manual | 1d | 2024-10-09 | 2024-10-10 |  |  |
| 199 | 1.8.2.4.3 | 基础设置报警管理 | manual | 1d | 2024-10-09 | 2024-10-10 |  |  |
| 200 | 1.8.2.4.4 | 监测预警数据查询 | manual | 1d | 2024-10-09 | 2024-10-10 |  |  |
| 201 | 1.8.2.4.5 | 监测预警统计分析 | manual | 1d | 2024-10-09 | 2024-10-10 |  |  |
| 202 | 1.8.2.4.6 | 监测预警预警分析 | manual | 1d | 2024-10-09 | 2024-10-10 |  |  |
| 203 | 1.8.2.4.7 | 应急指挥排水管网运行调度 | manual | 1d | 2024-10-09 | 2024-10-10 |  |  |
| 204 | 1.8.2.4.8 | 应急指挥城市暴雨内涝应急指挥 | manual | 1d | 2024-10-09 | 2024-10-10 |  |  |
| 205 | 1.8.2.4.9 | 应急指挥排水管网养护管理 | manual | 1d | 2024-10-09 | 2024-10-10 |  |  |

| ID | WBS | Task | Type | Duration | Start | Finish | Resources | Work |
| --- | --- | --- | --- | --- | --- | --- | --- | --- |
| 206 | 1.8.2.5 | **排水物联管理** |  | 14d | 2024-11-11 | 2024-11-28 |  |  |
| 207 | 1.8.2.5.1 | 物联感知网络结构 | manual | 1d | 2024-11-11 | 2024-11-12 |  |  |
| 208 | 1.9 | **九.数字展厅** |  | 127d | 2024-07-01 | 2024-12-24 | 董先超 | 1016h |
| 209 | 1.9.1 | 1.需求调研 | manual | 9d | 2024-07-16 | 2024-07-26 |  |  |
| 210 | 1.9.2 | **2.系统软件开发** |  | 82d | 2024-09-02 | 2024-12-24 |  |  |
| 211 | 1.9.2.1 | **智慧农业展厅** |  | 82d | 2024-09-02 | 2024-12-24 |  |  |
| 212 | 1.9.2.1.1 | 虚拟迎宾系统 | manual | 1d | 2024-09-02 | 2024-09-03 |  |  |
| 213 | 1.9.2.1.2 | 电子沙盘系统 | manual | 1d | 2024-09-02 | 2024-09-03 |  |  |
| 214 | 1.9.2.1.3 | 地画互动投影 | manual | 1d | 2024-09-02 | 2024-09-03 |  |  |
| 215 | 1.9.2.1.4 | 中控系统 | manual | 1d | 2024-09-02 | 2024-09-03 |  |  |
| 216 | 1.9.2.1.5 | 互动签名拍照系统 | manual | 1d | 2024-09-02 | 2024-09-03 |  |  |
